Schedule from MS Project, 2025-02-28 to 2029-07-10, A marks actual dates.

## Calendars

- 7 dní: Mon-Sun 08:00-16:00.

## Resources

| Resource |
| --- |
| USSK |
| MoE |
| USSK / Moe |
| OEMs |
| USSK / OEM |
| EPCMs |
| USSK / EPCM |
| OEM |
| EPCM |
| Frame company |
| EPCM / State Authorities |
| Frame eng. |
| State Authority |
| External company |
| OEM, EPCM |
| USSK/OEMs |

## Schedule

| ID | WBS | Task | Type | Duration | Start | Finish | Predecessors | Complete | Remaining | Total slack | Free slack | Constraint | Resources | Work | Actual work |
| --- | --- | --- | --- | --- | --- | --- | --- | --- | --- | --- | --- | --- | --- | --- | --- |
| 1 | 1 | **ASU Plant** |  | 1594d | 2025-02-28 A | 2029-07-10 |  | 4% | 1534.07d | 0d |  |  |  | 36360h | 1526.4h |
| 2 | 1.1 | **EU FUNDING** |  | 273d | 2025-02-28 A | 2025-11-27 |  | 27% | 199.2d | 1321d |  |  |  | 2184h | 590.4h |
| 3 | 1.1.1 | Application preparation |  | 123d | 2025-02-28 A | 2025-06-30 |  | 60% | 49.2d | 1321d | 0d | start no earlier than 2025-02-28 | USSK | 984h | 590.4h |
| 4 | 1.1.2 | Application submission | milestone | 0d | 2025-06-30 | 2025-06-30 | 3 |  |  | 1295d | 0d |  | USSK |  |  |
| 5 | 1.1.3 | Application evaulation |  | 120d | 2025-07-01 | 2025-10-28 | 4 |  |  | 1295d | 0d |  | MoE | 960h |  |
| 6 | 1.1.4 | Grant agreement signature procedure |  | 30d | 2025-10-29 | 2025-11-27 | 5 |  |  | 1295d | 0d |  | USSK / Moe | 240h |  |
| 7 | 1.1.5 | Grant agreement signature | milestone | 0d | 2025-11-27 | 2025-11-27 | 6 |  |  | 1295d |  |  |  |  |  |
| 8 | 1.2 | **PDS** |  | 198d | 2025-04-15 A | 2025-10-30 |  |  | 198d | 0d |  |  |  |  |  |
| 9 | 1.2.1 | PAEE | milestone, manual | 0d | 2025-04-15 A | 2025-04-15 A |  | 100% |  |  |  |  | USSK |  |  |
| 10 | 1.2.2 | AR | milestone, manual | 0d | 2025-10-30 | 2025-10-30 |  |  |  |  |  |  | USSK |  |  |
| 11 | 1.3 | **PROCUREMENT & CONTRACTING** |  | 997d | 2025-02-28 A | 2027-11-21 |  | 12% | 876.12d | 597d |  |  |  | 4440h | 936h |
| 12 | 1.3.1 | **OEM** |  | 367d | 2025-02-28 A | 2026-03-01 |  | 29% | 258.84d | 1227d |  |  |  | 3176h | 936h |
| 13 | 1.3.1.1 | **Market research** |  | 93d | 2025-02-28 A | 2025-05-31 |  | 90% | 9d | 1501d |  |  |  | 744h | 672h |
| 14 | 1.3.1.1.1 | RFI preparation | manual | 22d | 2025-02-28 A | 2025-03-21 A |  | 100% |  |  |  |  | USSK | 176h | 176h |
| 15 | 1.3.1.1.2 | Initial calls with potential OEMs |  | 3d | 2025-03-22 A | 2025-03-24 A | 14 | 100% |  |  |  |  | USSK | 24h | 24h |
| 16 | 1.3.1.1.3 | OEMs response |  | 38d | 2025-03-25 A | 2025-05-01 A | 15 | 100% |  |  |  |  | OEMs | 304h | 304h |
| 17 | 1.3.1.1.4 | USSK evaulation |  | 30d | 2025-05-02 A | 2025-05-31 | 16 | 70% | 9d | 1501d | 0d |  | USSK | 240h | 168h |
| 18 | 1.3.1.2 | **OEM selection** |  | 304d | 2025-05-02 A | 2026-03-01 |  | 11% | 271d | 0d |  |  |  | 2432h | 264h |
| 19 | 1.3.1.2.1 | Technical specification& RFP for OEM selection |  | 55d | 2025-05-02 A | 2025-06-25 | 17SS | 60% | 22d | 0d |  |  | USSK | 440h | 264h |
| 20 | 1.3.1.2.2 | OEMs proposals I.round |  | 92d | 2025-06-26 | 2025-09-25 | 19 |  |  | 0d |  |  | OEMs | 736h |  |
| 21 | 1.3.1.2.3 | USSK evaulation & clarification of proposals I.round |  | 51d | 2025-09-26 | 2025-11-15 | 20 |  |  | 0d |  |  | USSK | 408h |  |
| 22 | 1.3.1.2.4 | Negotiation RFQ package and preparation update for II.round |  | 30d | 2025-11-16 | 2025-12-15 | 21 |  |  | 0d |  |  | USSK/OEMs | 240h |  |
| 23 | 1.3.1.2.5 | OEMs proposals II.round |  | 46d | 2025-12-16 | 2026-01-30 | 22 |  |  | 0d |  |  | OEMs | 368h |  |
| 24 | 1.3.1.2.6 | USSK evaulation proposal II.round |  | 21d | 2026-01-31 | 2026-02-20 | 23 |  |  | 0d |  |  | USSK | 168h |  |
| 25 | 1.3.1.2.7 | Selection and OEM contract signature |  | 9d | 2026-02-21 | 2026-03-01 | 24, 10 |  |  | 0d |  |  | USSK / OEM | 72h |  |

| ID | WBS | Task | Type | Duration | Start | Finish | Predecessors | Total slack | Free slack | Resources | Work |
| --- | --- | --- | --- | --- | --- | --- | --- | --- | --- | --- | --- |
| 26 | 1.3.2 | **EPCM** |  | 276d | 2025-05-01 | 2026-01-31 |  | 0d |  |  | 1264h |
| 27 | 1.3.2.1 | **Stage I** |  | 0d | 2025-05-01 | 2025-05-01 |  | 0d |  |  |  |
| 28 | 1.3.2.1.1 | Contract for USSK technical support (OEM technical specification) | milestone, manual | 0d | 2025-05-01 | 2025-05-01 |  |  |  | USSK |  |
| 29 | 1.3.2.2 | **Stage II** |  | 158d | 2025-08-27 | 2026-01-31 |  | 29d |  |  | 1264h |
| 30 | 1.3.2.2.1 | Technical specification preparation for EPCM selection |  | 56d | 2025-08-27 | 2025-10-21 | 20FS-30d | 29d | 0d | USSK | 448h |
| 31 | 1.3.2.2.2 | EPCM proposals |  | 62d | 2025-10-22 | 2025-12-22 | 30 | 29d | 0d | EPCMs | 496h |
| 32 | 1.3.2.2.3 | USSK evaulation |  | 25d | 2025-12-23 | 2026-01-16 | 31 | 29d | 0d | USSK | 200h |
| 33 | 1.3.2.2.4 | Contract preparation |  | 15d | 2026-01-17 | 2026-01-31 | 32 | 29d | 0d | USSK | 120h |
| 34 | 1.3.2.2.5 | EPCM contract signed | milestone | 0d | 2026-01-31 | 2026-01-31 | 33, 10 | 29d | 0d | USSK / EPCM |  |
| 35 | 1.3.3 | **Engineering Frame contractor for EIA** |  | 0d | 2025-05-01 | 2025-05-01 |  | 0d |  |  |  |
| 36 | 1.3.3.1 | Selection& contract signed | milestone, manual | 0d | 2025-05-01 | 2025-05-01 |  |  |  |  |  |
| 37 | 1.3.4 | **Construction companies** |  | 659d | 2026-02-01 | 2027-11-21 |  | 232d |  |  |  |
| 38 | 1.3.4.1 | ASU Preparation works companies selection and signed contracts |  | 120d | 2026-02-01 | 2026-05-31 | 34 | 349d | 0d |  |  |
| 39 | 1.3.4.2 | ASU TOPs construction companies selection & contracts signed |  | 170d | 2026-06-01 | 2026-11-17 | 38 | 591d | 0d |  |  |
| 40 | 1.3.4.3 | ASU Plant construction companies selection& contracts signed |  | 120d | 2027-07-25 | 2027-11-21 | 56 | 0d |  |  |  |
| 41 | 1.4 | **ENGINEERING DEVELOPMENT** |  | 815d | 2025-05-01 | 2027-07-24 |  | 0d |  |  | 12440h |
| 42 | 1.4.1 | **OEM** |  | 390d | 2026-03-02 | 2027-03-26 |  | 0d |  |  | 3120h |
| 43 | 1.4.1.1 | Basic engineering development |  | 150d | 2026-03-02 | 2026-07-29 | 25 | 0d |  | OEM | 1200h |
| 44 | 1.4.1.2 | Detail engineering development |  | 240d | 2026-07-30 | 2027-03-26 | 43 | 30d |  | OEM | 1920h |
| 45 | 1.4.2 | **EPCM** |  | 420d | 2026-03-02 | 2027-04-25 |  | 0d |  |  | 3360h |
| 46 | 1.4.2.1 | Basic engineering development |  | 180d | 2026-03-02 | 2026-08-28 | 43SS, 34 | 0d |  | EPCM | 1440h |
| 47 | 1.4.2.2 | Detail engineering development |  | 240d | 2026-08-29 | 2027-04-25 | 46, 44SS | 0d |  | EPCM | 1920h |
| 48 | 1.4.3 | **Permit engineering** |  | 815d | 2025-05-01 | 2027-07-24 |  | 0d |  |  | 5960h |
| 49 | 1.4.3.1 | **EIA preparation** |  | 243d | 2025-05-01 | 2025-12-29 |  | 102d |  |  | 1720h |
| 50 | 1.4.3.1.1 | draft version |  | 120d | 2025-05-01 | 2025-08-28 | 36, 28 | 100d | 91d | Frame eng. | 960h |
| 51 | 1.4.3.1.2 | final version |  | 95d | 2025-09-26 | 2025-12-29 | 50, 20 | 123d | 0d | Frame eng. | 760h |
| 52 | 1.4.3.2 | Land use engineering preparation |  | 150d | 2026-04-01 | 2026-08-28 | 51, 34, 25, 43FF, 46FF | 10d | 0d | EPCM | 1200h |
| 53 | 1.4.3.3 | Land use external statements |  | 60d | 2026-08-29 | 2026-10-27 | 52 | 110d | 0d | EPCM / State Authorities | 480h |
| 54 | 1.4.3.4 | Building engineering preparation |  | 170d | 2026-08-29 | 2027-02-14 | 43, 46, 52 | 30d | 0d | EPCM | 1360h |
| 55 | 1.4.3.5 | Building external statements |  | 60d | 2027-02-15 | 2027-04-15 | 54 | 30d | 0d | EPCM / State Authorities | 480h |
| 56 | 1.4.3.6 | Tender engineering preparation |  | 90d | 2027-04-26 | 2027-07-24 | 54, 47 | 0d |  | EPCM | 720h |

| ID | WBS | Task | Type | Duration | Start | Finish | Predecessors | Total slack | Free slack | Resources | Work |
| --- | --- | --- | --- | --- | --- | --- | --- | --- | --- | --- | --- |
| 57 | 1.5 | **PERMITTING** |  | 682d | 2025-12-30 | 2027-11-11 |  | 10d |  |  | 3360h |
| 58 | 1.5.1 | EIA permit |  | 150d | 2025-12-30 | 2026-05-28 | 51 | 263d | 153d | State Authority | 1200h |
| 59 | 1.5.2 | Land use permit |  | 90d | 2026-10-28 | 2027-01-25 | 58, 53 | 110d | 80d | State Authority | 720h |
| 60 | 1.5.3 | IPPC permit |  | 180d | 2027-04-16 | 2027-10-12 | 59, 55 | 30d | 0d | State Authority | 1440h |
| 61 | 1.5.4 | Time contingency |  | 30d | 2027-10-13 | 2027-11-11 | 60 | 30d | 0d |  |  |
| 62 | 1.5.5 | Valid permits for construction | milestone | 0d | 2027-11-11 | 2027-11-11 | 61 | 30d |  | USSK |  |
| 63 | 1.6 | **DELIVERIES** |  | 600d | 2026-03-02 | 2027-10-22 |  | 30d |  |  | 4800h |
| 64 | 1.6.1 | **OEM** |  | 600d | 2026-03-02 | 2027-10-22 |  | 30d |  |  | 4800h |
| 65 | 1.6.1.1 | OEM equipment manufacturing |  | 540d | 2026-03-02 | 2027-08-23 | 25 | 50d | 0d | OEM | 4320h |
| 66 | 1.6.1.2 | OEM equipment transportation to USSK |  | 60d | 2027-08-24 | 2027-10-22 | 65 | 30d | 0d | OEM | 480h |
| 67 | 1.6.1.3 | OEM equipment on site | milestone | 0d | 2027-10-22 | 2027-10-22 | 66 | 50d |  | OEM |  |
| 68 | 1.7 | **CONSTRUCTION** |  | 989d | 2026-06-01 | 2029-02-13 |  | 147d |  |  | 7960h |
| 69 | 1.7.1 | Early works |  | 180d | 2026-06-01 | 2026-11-27 | 38 | 349d |  | External company | 1440h |
| 70 | 1.7.2 | ASU TOPs |  | 365d | 2026-11-18 | 2027-11-17 | 39 | 591d |  | External company | 2920h |
| 71 | 1.7.3 | ASU contruction |  | 450d | 2027-11-22 | 2029-02-13 | 69, 67, 40, 62 | 0d |  | External company | 3600h |
| 72 | 1.8 | **COMMISSIONING** |  | 237d | 2028-11-16 | 2029-07-10 |  | 0d |  |  | 1176h |
| 73 | 1.8.1 | ASU cold commissioning |  | 90d | 2028-11-16 | 2029-02-13 | 71FF | 0d |  |  |  |
| 74 | 1.8.2 | ASU hot commissioning |  | 90d | 2029-02-14 | 2029-05-14 | 71, 73 | 0d |  | OEM, EPCM | 720h |
| 75 | 1.8.3 | Performance guarantee |  | 57d | 2029-05-15 | 2029-07-10 | 74 | 0d |  | OEM, EPCM | 456h |
